Schedule from MS Project MPX, 2017-01-13 to 2017-02-15, A marks actual dates.

## Schedule

| ID | WBS | Task | Duration | Finish | Predecessors | Complete | Actual start | Text1 |
| --- | --- | --- | --- | --- | --- | --- | --- | --- |
| 1 | 1 | To display the category (Text1) and description (Task2) you will need to manually add them to the columns that are displayed. |  |  |  |  |  |  |
| 3 | 3 | **Project Kick-off** | 1.12d | 2017-01-16 |  | 100% | 2017-01-13 |  |
| 4 | 3.1 | Project Brief | 0.12d | 2017-01-13 |  | 100% | 2017-01-13 | Project Management |
| 5 | 3.2 | Complete project schedule | 1d | 2017-01-16 | 4 | 100% | 2017-01-13 | Project Management |
| 6 | 4 | **Copy/Layout** | 1.25d | 2017-01-17 |  | 100% | 2017-01-16 |  |
| 7 | 4.1 | Develop Copy | 0.12d | 2017-01-16 | 5 | 100% | 2017-01-16 | Writing |
| 8 | 4.2 | Develop Layout | 1d | 2017-01-17 | 7 | 100% | 2017-01-16 | Design |
| 9 | 4.3 | Copy Edits | 0.12d | 2017-01-17 | 8 | 100% | 2017-01-17 | Writing |
| 10 | 4.4 | Layout Edits | 0.12d | 2017-01-17 | 8 | 100% | 2017-01-17 | Design |
| 11 | 5 | **Proofing** | 10.62d | 2017-01-31 |  | 100% | 2017-01-17 |  |
| 12 | 5.1 | Proofing Edits | 0.12d | 2017-01-17 | 9 | 100% | 2017-01-17 | Proofing |
| 13 | 5.2 | HTML Layout | 5d | 2017-01-24 | 12 | 100% | 2017-01-17 | Web |
| 14 | 5.3 | Digital Review | 0.5d | 2017-01-24 | 13 | 100% | 2017-01-24 | Review |
| 15 | 5.4 | Edits from Digital Review | 0.5d | 2017-01-25 | 14 | 100% | 2017-01-25 | Web |
| 16 | 5.5 | Marketing Email Review | 1d | 2017-01-26 | 15 | 100% | 2017-01-25 | Review |
| 17 | 5.6 | Marketing Edits | 1d | 2017-01-27 | 16 | 100% | 2017-01-26 | Writing |
| 18 | 5.7 | Final Proof | 1d | 2017-01-30 | 17 | 100% | 2017-01-27 | Proofing |
| 19 | 5.8 | Send final preview to client | 1d | 2017-01-31 | 18 | 100% | 2017-01-30 | Review |
| 20 | 5.9 | Final email edits | 0.5d | 2017-01-31 | 19 | 100% | 2017-01-31 | Web |
| 21 | 6 | **Production** | 11d | 2017-02-15 |  | 100% | 2017-02-01 |  |
| 22 | 6.1 | Email list Finalized | 4d | 2017-02-06 | 20 | 100% | 2017-02-01 | Operations |
| 23 | 6.2 | Confirm Email Sent (constituent records tagged) | 7d | 2017-02-15 | 22 | 100% | 2017-02-07 | Production |
